# Kalle Kuja - Autotalli

Schedule from MS Project, 2016-07-04 to 2016-07-29, 7.5 hours a day, costs in €.
Kalle Kujan autotallin rakentaminen
Ornanet Koulutus

## Calendars

- Vakio: Mon-Fri 07:00-11:00, 11:30-15:00; Sat-Sun off. Exceptions (off unless hours are given): 2015-12-24 to 2024-12-24 (Jouluaatto, recurring), 2015-12-25 to 2024-12-25 (Joulupäivä, recurring), 2015-12-26 to 2024-12-26 (Tapaninpäivä, recurring), 2016-01-01 to 2025-01-01 (Uudenvuoden päivä, recurring), 2016-05-01 to 2025-05-01 (Vappu, recurring).

## Resources

| Resource | Rate | Cost per use |
| --- | --- | --- |
| Kari Keinonen | 45 |  |
| Kalle Kuja |  |  |
| Kaivinkone | 66 |  |
| Kirvesmies 1 | 26.5 |  |
| Kirvesmies 2 | 25.5 |  |
| Apumies | 16.5 |  |
| Raudoittaja |  | 400 |
| Sähkömies |  | 650 |
| Maalari |  | 750 |
| Teräkset |  | 380 |
| Betoni |  | 320 |
| Sadevesiviemärit |  | 90 |
| Sadevesikourut |  | 220 |

## Schedule

| ID | WBS | Task | Type | Duration | Start | Finish | Predecessors | Total slack | Free slack | Constraint | Resources | Work | Cost |
| --- | --- | --- | --- | --- | --- | --- | --- | --- | --- | --- | --- | --- | --- |
| 1 | 1 | **Kalle Kuja - autotalli** |  | 18.43d | 2016-07-04 | 2016-07-28 |  | 0.1d |  |  |  | 379.62h | 18,803.31 |
| 2 | 1.1 | PROJEKTIN ALOITUS | milestone | 0d | 2016-07-04 | 2016-07-04 |  | 0.1d | 0d |  |  |  | 7,500 |
| 3 | 1.2 | **PERUSTUSTYÖT** |  | 5d | 2016-07-04 | 2016-07-08 |  | 0d |  |  |  | 116.62h | 3,511.06 |
| 4 | 1.2.1 | Rakennuspaikan merkitseminen |  | 1d | 2016-07-04 | 2016-07-04 | 2 | 0.1d | 0d |  | Kirvesmies 2; Kirvesmies 1; Apumies | 22.5h | 513.75 |
| 5 | 1.2.2 | Perustusten kaivuu |  | 5.5h | 2016-07-04 | 2016-07-04 | 4FF | 0.1d | 0d |  | Kaivinkone | 5.5h | 363 |
| 6 | 1.2.3 | Valurungon laudoitus |  | 2.5d | 2016-07-05 | 2016-07-07 | 5 | 0.1d | 0d |  | Kirvesmies 1; Kirvesmies 2; Apumies [50%] | 46.88h | 1,129.69 |
| 7 | 1.2.4 | Raudoitustyö |  | 3d | 2016-07-05 | 2016-07-08 | 6FS-2d | 0.1d |  |  | Raudoittaja; Apumies [50%]; Teräkset | 33.75h | 965.62 |
| 8 | 1.2.5 | Raudoitustarkastus |  | 2h | 2016-07-08 | 2016-07-08 | 7FF | 0d |  | must start on 2016-07-08 | Kari Keinonen | 2h | 90 |
| 9 | 1.2.6 | Perustusten valu |  | 3h | 2016-07-08 | 2016-07-08 | 8 | 0d |  | must finish on 2016-07-08 | Kirvesmies 1; Apumies; Betoni | 6h | 449 |
| 10 | 1.3 | PERUSTUSTYÖT VALMIIT | milestone | 0d | 2016-07-08 | 2016-07-08 | 3FF, 9 | 0.33d | 0d |  |  |  |  |
| 11 | 1.4 | **RUNKOTYÖT** |  | 4.67d | 2016-07-11 | 2016-07-15 | 10 | 0.33d | 0d |  |  | 73.5h | 1,922.25 |
| 12 | 1.4.1 | Valurungon purkaminen |  | 5h | 2016-07-11 | 2016-07-11 | 9FS+2ed | 0.33d | 0d |  | Kirvesmies 1; Kirvesmies 2; Apumies | 15h | 342.5 |
| 13 | 1.4.2 | Sadevesiviemärien asentaminen |  | 4h | 2016-07-11 | 2016-07-12 | 12 | 3.8d |  |  | Kirvesmies 1; Sadevesiviemärit; Kalle Kuja [50%] | 6h | 196 |
| 14 | 1.4.3 | Maatyöt (pihan viimeistely) |  | 5h | 2016-07-11 | 2016-07-12 | 12 | 3.67d |  |  | Kaivinkone; Apumies [50%] | 7.5h | 371.25 |
| 15 | 1.4.4 | Kantavan rungon pystytys |  | 4d | 2016-07-11 | 2016-07-15 | 12 | 0.33d | 0d | finish no later than 2016-07-15 | Kirvesmies 2; Apumies [50%] | 45h | 1,012.5 |
| 16 | 1.5 | RUNKOTYÖT VALMIIT | milestone | 0d | 2016-07-15 | 2016-07-15 | 11FF | 0.33d | 0d |  |  |  |  |
| 17 | 1.6 | **KATTOTYÖT** |  | 4.5d | 2016-07-15 | 2016-07-22 | 16 | 0.33d | 0d |  |  | 78.75h | 1,805.62 |
| 18 | 1.6.1 | Kattotuolien asennus |  | 2.5d | 2016-07-15 | 2016-07-20 | 15 | 0.33d | 0d | start no later than 2016-07-18 | Kirvesmies 1; Kirvesmies 2; Apumies | 56.25h | 1,284.38 |
| 19 | 1.6.2 | Aluskatteen asennus |  | 1d | 2016-07-20 | 2016-07-21 | 18 | 2.3d | 0d |  | Kirvesmies 1; Apumies [50%] | 11.25h | 260.62 |
| 20 | 1.6.3 | Kattotiilien asennus |  | 1d | 2016-07-21 | 2016-07-22 | 19 | 5.83d | 0d |  | Kirvesmies 1; Apumies [50%] | 11.25h | 260.62 |
| 21 | 1.7 | KATTOTYÖT VALMIIT | milestone | 0d | 2016-07-22 | 2016-07-22 | 17FF, 20 | 5.83d |  |  |  |  |  |
| 22 | 1.8 | **VERHOUSTYÖT** |  | 6.27d | 2016-07-20 | 2016-07-28 |  | 0.83d | 0d |  |  | 110.75h | 4,064.38 |
| 23 | 1.8.1 | Ulkoverhouksen tekeminen |  | 2d | 2016-07-20 | 2016-07-22 | 18 | 0.83d | 0d |  | Kirvesmies 2; Apumies [50%] | 22.5h | 506.25 |
| 24 | 1.8.2 | Sisäkaton asentaminen |  | 1d | 2016-07-22 | 2016-07-25 | 19, 23 | 1.3d | 0d |  | Kirvesmies 2; Apumies [50%] | 11.25h | 253.12 |
| 25 | 1.8.3 | Sisäverhouksen tekeminen |  | 3d | 2016-07-25 | 2016-07-28 | 24, 27 | 1.3d | 0d |  | Kirvesmies 1; Apumies [50%] | 33.75h | 781.88 |
| 26 | 1.8.4 | Sadevesikourujen asennus |  | 1d | 2016-07-22 | 2016-07-25 | 23 | 4.57d |  |  | Kirvesmies 2; Apumies [50%]; Sadevesikourut | 11.25h | 473.12 |
| 27 | 1.8.5 | Sähköasennukset |  | 1d | 2016-07-22 | 2016-07-25 | 23 | 1.3d | 0d |  | Sähkömies | 7.5h | 650 |
| 28 | 1.8.6 | Valaisimien asennus |  | 2h | 2016-07-28 | 2016-07-28 | 24, 25 | 1.3d |  |  | Sähkömies | 2h | 650 |
| 29 | 1.8.7 | Maalaustyöt |  | 3d | 2016-07-22 | 2016-07-27 | 23 | 0.83d |  | start no later than 2016-07-25 | Maalari | 22.5h | 750 |
| 30 | 1.9 | VERHOUSTYÖT VALMIIT | milestone | 0d | 2016-07-28 | 2016-07-28 | 22FF, 29 | 1.3d |  |  |  |  |  |
| 31 | 2 | PROJEKTI VALMIS | milestone | 2h | 2016-07-29 | 2016-07-29 | 1FF, 30 | 0d |  | must finish on 2016-07-29 | Kari Keinonen | 2h | 90 |
