# Kalle Kuja - Autotalli

Schedule from MS Project, 2016-07-04 to 2016-07-29, 7.5 hours a day, costs in €.
Kalle Kujan autotallin rakentaminen
Ornanet Koulutus

## Calendars

- Vakio: Mon-Fri 07:00-11:00, 11:30-15:00; Sat-Sun off. Exceptions (off unless hours are given): 2015-12-24 to 2024-12-24 (Jouluaatto, recurring), 2015-12-25 to 2024-12-25 (Joulupäivä, recurring), 2015-12-26 to 2024-12-26 (Tapaninpäivä, recurring), 2016-01-01 to 2025-01-01 (Uudenvuoden päivä, recurring), 2016-05-01 to 2025-05-01 (Vappu, recurring).

## Resources

| Resource | Rate | Cost per use |
| --- | --- | --- |
| Kari Keinonen | 45 |  |
| Kalle Kuja |  |  |
| Kaivinkone | 66 |  |
| Kirvesmies 1 | 26.5 |  |
| Kirvesmies 2 | 25.5 |  |
| Apumies | 16.5 |  |
| Raudoittaja |  | 400 |
| Sähkömies |  | 650 |
| Maalari |  | 750 |
| Teräkset |  | 380 |
| Betoni |  | 320 |
| Sadevesiviemärit |  | 90 |
| Sadevesikourut |  | 220 |

## Schedule

| ID | WBS | Task | Type | Duration | Start | Finish | Predecessors | Baseline start | Baseline finish | Baseline duration | Total slack | Free slack | Constraint | Resources | Work | Cost | Baseline cost |
| --- | --- | --- | --- | --- | --- | --- | --- | --- | --- | --- | --- | --- | --- | --- | --- | --- | --- |
| 1 | 1 | **Kalle Kuja - autotalli** |  | 19.17d | 2016-07-04 | 2016-07-29 |  | 2016-07-04 | 2016-07-29 | 19.17d | 0.1d |  |  |  | 379.62h | 18,508 | 18,508 |
| 2 | 1.1 | PROJEKTIN ALOITUS | milestone | 0d | 2016-07-04 | 2016-07-04 |  | 2016-07-04 | 2016-07-04 |  | 0.1d | 0d |  |  |  | 7,500 | 7,500 |
| 3 | 1.2 | **PERUSTUSTYÖT** |  | 5d | 2016-07-04 | 2016-07-08 |  | 2016-07-04 | 2016-07-08 | 5d | 0d |  |  |  | 116.62h | 3,511.06 | 3,511.06 |
| 4 | 1.2.1 | Rakennuspaikan merkitseminen |  | 1d | 2016-07-04 | 2016-07-04 | 2 | 2016-07-04 | 2016-07-04 | 1d | 0.1d | 0d |  | Kirvesmies 2; Kirvesmies 1; Apumies | 22.5h | 513.75 | 513.75 |
| 5 | 1.2.2 | Perustusten kaivuu |  | 5.5h | 2016-07-04 | 2016-07-04 | 4FF | 2016-07-04 | 2016-07-04 | 5.5h | 0.1d | 0d |  | Kaivinkone | 5.5h | 363 | 363 |
| 6 | 1.2.3 | Valurungon laudoitus |  | 2.5d | 2016-07-05 | 2016-07-07 | 5 | 2016-07-05 | 2016-07-07 | 2.5d | 0.1d | 0d |  | Kirvesmies 1; Kirvesmies 2; Apumies [50%] | 46.88h | 1,129.69 | 1,129.69 |
| 7 | 1.2.4 | Raudoitustyö |  | 3d | 2016-07-05 | 2016-07-08 | 6FS-2d | 2016-07-05 | 2016-07-08 | 3d | 0.1d |  |  | Raudoittaja; Apumies [50%]; Teräkset | 33.75h | 965.62 | 965.62 |
| 8 | 1.2.5 | Raudoitustarkastus |  | 2h | 2016-07-08 | 2016-07-08 | 7FF | 2016-07-08 | 2016-07-08 | 2h | 0d |  | must start on 2016-07-08 | Kari Keinonen | 2h | 90 | 90 |
| 9 | 1.2.6 | Perustusten valu |  | 3h | 2016-07-08 | 2016-07-08 | 8 | 2016-07-08 | 2016-07-08 | 3h | 0d |  | must finish on 2016-07-08 | Kirvesmies 1; Apumies; Betoni | 6h | 449 | 449 |
| 10 | 1.3 | PERUSTUSTYÖT VALMIIT | milestone | 0d | 2016-07-08 | 2016-07-08 | 3FF, 9 | 2016-07-08 | 2016-07-08 |  | 0.33d | 0d |  |  |  |  |  |
| 11 | 1.4 | **RUNKOTYÖT** |  | 4.67d | 2016-07-11 | 2016-07-15 | 10 | 2016-07-11 | 2016-07-15 | 4.67d | 0.33d | 0d |  |  | 73.5h | 1,922.25 | 1,922.25 |
| 12 | 1.4.1 | Valurungon purkaminen |  | 5h | 2016-07-11 | 2016-07-11 | 9FS+2ed | 2016-07-11 | 2016-07-11 | 5h | 0.33d | 0d |  | Kirvesmies 1; Kirvesmies 2; Apumies | 15h | 342.5 | 342.5 |
| 13 | 1.4.2 | Sadevesiviemärien asentaminen |  | 4h | 2016-07-11 | 2016-07-12 | 12 | 2016-07-11 | 2016-07-12 | 4h | 3.8d |  |  | Kirvesmies 1; Sadevesiviemärit; Kalle Kuja [50%] | 6h | 196 | 196 |
| 14 | 1.4.3 | Maatyöt (pihan viimeistely) |  | 5h | 2016-07-11 | 2016-07-12 | 12 | 2016-07-11 | 2016-07-12 | 5h | 3.67d |  |  | Kaivinkone; Apumies [50%] | 7.5h | 371.25 | 371.25 |
| 15 | 1.4.4 | Kantavan rungon pystytys |  | 4d | 2016-07-11 | 2016-07-15 | 12 | 2016-07-11 | 2016-07-15 | 4d | 0.33d | 0d | finish no later than 2016-07-15 | Kirvesmies 2; Apumies [50%] | 45h | 1,012.5 | 1,012.5 |
| 16 | 1.5 | RUNKOTYÖT VALMIIT | milestone | 0d | 2016-07-15 | 2016-07-15 | 11FF | 2016-07-15 | 2016-07-15 |  | 0.33d | 0d |  |  |  |  |  |
| 17 | 1.6 | **KATTOTYÖT** |  | 4.5d | 2016-07-15 | 2016-07-22 | 16 | 2016-07-15 | 2016-07-22 | 4.5d | 0.33d | 0d |  |  | 78.75h | 1,805.62 | 1,805.62 |
| 18 | 1.6.1 | Kattotuolien asennus |  | 2.5d | 2016-07-15 | 2016-07-20 | 15 | 2016-07-15 | 2016-07-20 | 2.5d | 0.33d | 0d | start no later than 2016-07-18 | Kirvesmies 1; Kirvesmies 2; Apumies | 56.25h | 1,284.38 | 1,284.38 |
| 19 | 1.6.2 | Aluskatteen asennus |  | 1d | 2016-07-20 | 2016-07-21 | 18 | 2016-07-20 | 2016-07-21 | 1d | 2.3d | 0d |  | Kirvesmies 1; Apumies [50%] | 11.25h | 260.62 | 260.62 |
| 20 | 1.6.3 | Kattotiilien asennus |  | 1d | 2016-07-21 | 2016-07-22 | 19 | 2016-07-21 | 2016-07-22 | 1d | 5.83d | 0d |  | Kirvesmies 1; Apumies [50%] | 11.25h | 260.62 | 260.62 |
| 21 | 1.7 | KATTOTYÖT VALMIIT | milestone | 0d | 2016-07-22 | 2016-07-22 | 17FF, 20 | 2016-07-22 | 2016-07-22 |  | 5.83d |  |  |  |  |  |  |
| 22 | 1.8 | **VERHOUSTYÖT** |  | 7d | 2016-07-20 | 2016-07-29 |  | 2016-07-20 | 2016-07-29 | 7d | 0.57d | 0d |  |  | 110.75h | 3,769.06 | 3,769.06 |
| 23 | 1.8.1 | Ulkoverhouksen tekeminen |  | 2d | 2016-07-20 | 2016-07-22 | 18 | 2016-07-20 | 2016-07-22 | 2d | 0.57d | 0d |  | Kirvesmies 2; Apumies [50%] | 22.5h | 506.25 | 506.25 |
| 24 | 1.8.2 | Sisäkaton asentaminen |  | 1d | 2016-07-22 | 2016-07-25 | 19, 23 | 2016-07-22 | 2016-07-25 | 1d | 1.3d | 0d |  | Kirvesmies 2; Apumies [50%] | 11.25h | 253.12 | 253.12 |
| 25 | 1.8.3 | Sisäverhouksen tekeminen |  | 3d | 2016-07-25 | 2016-07-28 | 24, 27 | 2016-07-25 | 2016-07-28 | 3d | 1.3d | 0d |  | Kirvesmies 1; Kalle Kuja [50%] | 33.75h | 596.25 | 596.25 |
| 26 | 1.8.4 | Sadevesikourujen asennus |  | 1.75d | 2016-07-22 | 2016-07-25 | 23 | 2016-07-22 | 2016-07-25 | 1.75d | 3.82d |  |  | Kirvesmies 2; Sadevesikourut; Kalle Kuja [50%] | 11.25h | 363.44 | 363.44 |
| 27 | 1.8.5 | Sähköasennukset |  | 1d | 2016-07-22 | 2016-07-25 | 23 | 2016-07-22 | 2016-07-25 | 1d | 1.3d | 0d |  | Sähkömies | 7.5h | 650 | 650 |
| 28 | 1.8.6 | Valaisimien asennus |  | 2h | 2016-07-28 | 2016-07-28 | 24, 25 | 2016-07-28 | 2016-07-28 | 2h | 1.3d |  |  | Sähkömies | 2h | 650 | 650 |
| 29 | 1.8.7 | Maalaustyöt |  | 3d | 2016-07-22 | 2016-07-29 | 23 | 2016-07-22 | 2016-07-29 | 3d | 0.57d | 0d | start no later than 2016-07-25 | Maalari | 22.5h | 750 | 750 |
| 30 | 1.9 | VERHOUSTYÖT VALMIIT | milestone | 0d | 2016-07-29 | 2016-07-29 | 22FF, 29 | 2016-07-29 | 2016-07-29 |  | 0.57d |  |  |  |  |  |  |
| 31 | 2 | PROJEKTI VALMIS | milestone | 2h | 2016-07-29 | 2016-07-29 | 1FF, 30 | 2016-07-29 | 2016-07-29 | 2h | 0d |  | must finish on 2016-07-29 | Kari Keinonen | 2h | 90 | 90 |
