# Kalle Kuja - Autotalli

Schedule from MS Project, 2016-07-04 to 2016-07-29, 7.5 hours a day, costs in €.
Kalle Kujan autotallin rakentaminen
Ornanet Koulutus

## Calendars

- Vakio: Mon-Fri 07:00-11:00, 11:30-15:00; Sat-Sun off. Exceptions (off unless hours are given): 2015-12-24 to 2024-12-24 (Jouluaatto, recurring), 2015-12-25 to 2024-12-25 (Joulupäivä, recurring), 2015-12-26 to 2024-12-26 (Tapaninpäivä, recurring), 2016-01-01 to 2025-01-01 (Uudenvuoden päivä, recurring), 2016-05-01 to 2025-05-01 (Vappu, recurring).

## Resources

| Resource | Rate | Cost per use |
| --- | --- | --- |
| Kari Keinonen | 45 |  |
| Kalle Kuja |  |  |
| Kaivinkone | 66 |  |
| Kirvesmies 1 | 26.5 |  |
| Kirvesmies 2 | 25.5 |  |
| Apumies | 16.5 |  |
| Raudoittaja |  | 400 |
| Sähkömies |  | 650 |
| Maalari |  | 750 |
| Teräkset |  | 380 |
| Betoni |  | 320 |
| Sadevesiviemärit |  | 90 |
| Sadevesikourut |  | 220 |

## Schedule

| ID | WBS | Task | Type | Duration | Start | Finish | Predecessors | Baseline start | Baseline finish | Baseline duration | Total slack | Free slack | Constraint | Resources | Work | Cost | Baseline cost |
| --- | --- | --- | --- | --- | --- | --- | --- | --- | --- | --- | --- | --- | --- | --- | --- | --- | --- |
| 1 | 1 | **Kalle Kuja - autotalli** |  | 19.17d | 2016-07-04 07:00 | 2016-07-29 08:15 |  | 2016-07-04 07:00 | 2016-07-29 08:15 | 19.17d | 0.1d |  |  |  | 401.62h | 19,498 | 19,498 |
| 2 | 1.1 | PROJEKTIN ALOITUS | milestone | 0d | 2016-07-04 07:00 | 2016-07-04 07:00 |  | 2016-07-04 07:00 | 2016-07-04 07:00 |  | 0.1d | 0d |  |  |  | 7,500 | 7,500 |
| 3 | 1.2 | **Työmaatarkastus** |  | 17.27d | 2016-07-04 07:00 | 2016-07-27 09:00 |  | 2016-07-04 07:00 | 2016-07-27 09:00 | 17.27d | 2.73d |  |  |  | 22h | 990 | 990 |
| 4 | 1.2.1 | Työmaatarkastus 1 |  | 2h | 2016-07-04 07:00 | 2016-07-04 09:00 |  | 2016-07-04 07:00 | 2016-07-04 09:00 | 2h | 19.73d |  | start no earlier than 2016-07-04 07:00 | Kari Keinonen | 2h | 90 | 90 |
| 5 | 1.2.2 | Työmaatarkastus 2 |  | 2h | 2016-07-06 07:00 | 2016-07-06 09:00 |  | 2016-07-06 07:00 | 2016-07-06 09:00 | 2h | 17.73d |  | start no earlier than 2016-07-06 07:00 | Kari Keinonen | 2h | 90 | 90 |
| 6 | 1.2.3 | Työmaatarkastus 3 |  | 2h | 2016-07-08 07:00 | 2016-07-08 09:00 |  | 2016-07-08 07:00 | 2016-07-08 09:00 | 2h | 15.73d |  | start no earlier than 2016-07-08 07:00 | Kari Keinonen | 2h | 90 | 90 |
| 7 | 1.2.4 | Työmaatarkastus 4 |  | 2h | 2016-07-11 07:00 | 2016-07-11 09:00 |  | 2016-07-11 07:00 | 2016-07-11 09:00 | 2h | 14.73d |  | start no earlier than 2016-07-11 07:00 | Kari Keinonen | 2h | 90 | 90 |
| 8 | 1.2.5 | Työmaatarkastus 5 |  | 2h | 2016-07-13 07:00 | 2016-07-13 09:00 |  | 2016-07-13 07:00 | 2016-07-13 09:00 | 2h | 12.73d |  | start no earlier than 2016-07-13 07:00 | Kari Keinonen | 2h | 90 | 90 |
| 9 | 1.2.6 | Työmaatarkastus 6 |  | 2h | 2016-07-15 07:00 | 2016-07-15 09:00 |  | 2016-07-15 07:00 | 2016-07-15 09:00 | 2h | 10.73d |  | start no earlier than 2016-07-15 07:00 | Kari Keinonen | 2h | 90 | 90 |
| 10 | 1.2.7 | Työmaatarkastus 7 |  | 2h | 2016-07-18 07:00 | 2016-07-18 09:00 |  | 2016-07-18 07:00 | 2016-07-18 09:00 | 2h | 9.73d |  | start no earlier than 2016-07-18 07:00 | Kari Keinonen | 2h | 90 | 90 |
| 11 | 1.2.8 | Työmaatarkastus 8 |  | 2h | 2016-07-20 07:00 | 2016-07-20 09:00 |  | 2016-07-20 07:00 | 2016-07-20 09:00 | 2h | 7.73d |  | start no earlier than 2016-07-20 07:00 | Kari Keinonen | 2h | 90 | 90 |
| 12 | 1.2.9 | Työmaatarkastus 9 |  | 2h | 2016-07-22 07:00 | 2016-07-22 09:00 |  | 2016-07-22 07:00 | 2016-07-22 09:00 | 2h | 5.73d |  | start no earlier than 2016-07-22 07:00 | Kari Keinonen | 2h | 90 | 90 |
| 13 | 1.2.10 | Työmaatarkastus 10 |  | 2h | 2016-07-25 07:00 | 2016-07-25 09:00 |  | 2016-07-25 07:00 | 2016-07-25 09:00 | 2h | 4.73d |  | start no earlier than 2016-07-25 07:00 | Kari Keinonen | 2h | 90 | 90 |
| 14 | 1.2.11 | Työmaatarkastus 11 |  | 2h | 2016-07-27 07:00 | 2016-07-27 09:00 |  | 2016-07-27 07:00 | 2016-07-27 09:00 | 2h | 2.73d |  | start no earlier than 2016-07-27 07:00 | Kari Keinonen | 2h | 90 | 90 |
| 15 | 1.3 | **PERUSTUSTYÖT** |  | 5d | 2016-07-04 07:00 | 2016-07-08 15:00 |  | 2016-07-04 07:00 | 2016-07-08 15:00 | 5d | 0d |  |  |  | 116.62h | 3,511.06 | 3,511.06 |
| 16 | 1.3.1 | Rakennuspaikan merkitseminen |  | 1d | 2016-07-04 07:00 | 2016-07-04 15:00 | 2 | 2016-07-04 07:00 | 2016-07-04 15:00 | 1d | 0.1d | 0d |  | Kirvesmies 2; Kirvesmies 1; Apumies | 22.5h | 513.75 | 513.75 |
| 17 | 1.3.2 | Perustusten kaivuu |  | 5.5h | 2016-07-04 09:00 | 2016-07-04 15:00 | 16FF | 2016-07-04 09:00 | 2016-07-04 15:00 | 5.5h | 0.1d | 0d |  | Kaivinkone | 5.5h | 363 | 363 |
| 18 | 1.3.3 | Valurungon laudoitus |  | 2.5d | 2016-07-05 07:00 | 2016-07-07 10:45 | 17 | 2016-07-05 07:00 | 2016-07-07 10:45 | 2.5d | 0.1d | 0d |  | Kirvesmies 1; Kirvesmies 2; Apumies [50%] | 46.88h | 1,129.69 | 1,129.69 |
| 19 | 1.3.4 | Raudoitustyö |  | 3d | 2016-07-05 10:45 | 2016-07-08 10:45 | 18FS-2d | 2016-07-05 10:45 | 2016-07-08 10:45 | 3d | 0.1d |  |  | Raudoittaja; Apumies [50%]; Teräkset | 33.75h | 965.62 | 965.62 |
| 20 | 1.3.5 | Raudoitustarkastus |  | 2h | 2016-07-08 09:30 | 2016-07-08 12:00 | 19FF | 2016-07-08 09:30 | 2016-07-08 12:00 | 2h | 0d |  | must start on 2016-07-08 09:30 | Kari Keinonen | 2h | 90 | 90 |
| 21 | 1.3.6 | Perustusten valu |  | 3h | 2016-07-08 12:00 | 2016-07-08 15:00 | 20 | 2016-07-08 12:00 | 2016-07-08 15:00 | 3h | 0d |  | must finish on 2016-07-08 15:00 | Kirvesmies 1; Apumies; Betoni | 6h | 449 | 449 |
| 22 | 1.4 | PERUSTUSTYÖT VALMIIT | milestone | 0d | 2016-07-08 15:00 | 2016-07-08 15:00 | 15FF, 21 | 2016-07-08 15:00 | 2016-07-08 15:00 |  | 0.33d | 0d |  |  |  |  |  |
| 23 | 1.5 | **RUNKOTYÖT** |  | 4.67d | 2016-07-11 07:00 | 2016-07-15 12:30 | 22 | 2016-07-11 07:00 | 2016-07-15 12:30 | 4.67d | 0.33d | 0d |  |  | 73.5h | 1,922.25 | 1,922.25 |
| 24 | 1.5.1 | Valurungon purkaminen |  | 5h | 2016-07-11 07:00 | 2016-07-11 12:30 | 21FS+2ed | 2016-07-11 07:00 | 2016-07-11 12:30 | 5h | 0.33d | 0d |  | Kirvesmies 1; Kirvesmies 2; Apumies | 15h | 342.5 | 342.5 |
| 25 | 1.5.2 | Sadevesiviemärien asentaminen |  | 4h | 2016-07-11 12:30 | 2016-07-12 08:30 | 24 | 2016-07-11 12:30 | 2016-07-12 08:30 | 4h | 3.8d |  |  | Kirvesmies 1; Sadevesiviemärit; Kalle Kuja [50%] | 6h | 196 | 196 |
| 26 | 1.5.3 | Maatyöt (pihan viimeistely) |  | 5h | 2016-07-11 12:30 | 2016-07-12 09:30 | 24 | 2016-07-11 12:30 | 2016-07-12 09:30 | 5h | 3.67d |  |  | Kaivinkone; Apumies [50%] | 7.5h | 371.25 | 371.25 |
| 27 | 1.5.4 | Kantavan rungon pystytys |  | 4d | 2016-07-11 12:30 | 2016-07-15 12:30 | 24 | 2016-07-11 12:30 | 2016-07-15 12:30 | 4d | 0.33d | 0d | finish no later than 2016-07-15 15:00 | Kirvesmies 2; Apumies [50%] | 45h | 1,012.5 | 1,012.5 |
| 28 | 1.6 | RUNKOTYÖT VALMIIT | milestone | 0d | 2016-07-15 12:30 | 2016-07-15 12:30 | 23FF | 2016-07-15 12:30 | 2016-07-15 12:30 |  | 0.33d | 0d |  |  |  |  |  |

| ID | WBS | Task | Type | Duration | Start | Finish | Predecessors | Baseline start | Baseline finish | Baseline duration | Total slack | Free slack | Constraint | Resources | Work | Cost | Baseline cost |
| --- | --- | --- | --- | --- | --- | --- | --- | --- | --- | --- | --- | --- | --- | --- | --- | --- | --- |
| 29 | 1.7 | **KATTOTYÖT** |  | 4.5d | 2016-07-15 12:30 | 2016-07-22 08:15 | 28 | 2016-07-15 12:30 | 2016-07-22 08:15 | 4.5d | 0.33d | 0d |  |  | 78.75h | 1,805.62 | 1,805.62 |
| 30 | 1.7.1 | Kattotuolien asennus |  | 2.5d | 2016-07-15 12:30 | 2016-07-20 08:15 | 27 | 2016-07-15 12:30 | 2016-07-20 08:15 | 2.5d | 0.33d | 0d | start no later than 2016-07-18 07:00 | Kirvesmies 1; Kirvesmies 2; Apumies | 56.25h | 1,284.38 | 1,284.38 |
| 31 | 1.7.2 | Aluskatteen asennus |  | 1d | 2016-07-20 08:15 | 2016-07-21 08:15 | 30 | 2016-07-20 08:15 | 2016-07-21 08:15 | 1d | 2.3d | 0d |  | Kirvesmies 1; Apumies [50%] | 11.25h | 260.62 | 260.62 |
| 32 | 1.7.3 | Kattotiilien asennus |  | 1d | 2016-07-21 08:15 | 2016-07-22 08:15 | 31 | 2016-07-21 08:15 | 2016-07-22 08:15 | 1d | 5.83d | 0d |  | Kirvesmies 1; Apumies [50%] | 11.25h | 260.62 | 260.62 |
| 33 | 1.8 | KATTOTYÖT VALMIIT | milestone | 0d | 2016-07-22 08:15 | 2016-07-22 08:15 | 29FF, 32 | 2016-07-22 08:15 | 2016-07-22 08:15 |  | 5.83d |  |  |  |  |  |  |
| 34 | 1.9 | **VERHOUSTYÖT** |  | 7d | 2016-07-20 08:15 | 2016-07-29 08:15 |  | 2016-07-20 08:15 | 2016-07-29 08:15 | 7d | 0.57d | 0d |  |  | 110.75h | 3,769.06 | 3,769.06 |
| 35 | 1.9.1 | Ulkoverhouksen tekeminen |  | 2d | 2016-07-20 08:15 | 2016-07-22 08:15 | 30 | 2016-07-20 08:15 | 2016-07-22 08:15 | 2d | 0.57d | 0d |  | Kirvesmies 2; Apumies [50%] | 22.5h | 506.25 | 506.25 |
| 36 | 1.9.2 | Sisäkaton asentaminen |  | 1d | 2016-07-22 08:15 | 2016-07-25 08:15 | 31, 35 | 2016-07-22 08:15 | 2016-07-25 08:15 | 1d | 1.3d | 0d |  | Kirvesmies 2; Apumies [50%] | 11.25h | 253.12 | 253.12 |
| 37 | 1.9.3 | Sisäverhouksen tekeminen |  | 3d | 2016-07-25 08:15 | 2016-07-28 08:15 | 36, 39 | 2016-07-25 08:15 | 2016-07-28 08:15 | 3d | 1.3d | 0d |  | Kirvesmies 1; Kalle Kuja [50%] | 33.75h | 596.25 | 596.25 |
| 38 | 1.9.4 | Sadevesikourujen asennus |  | 1.75d | 2016-07-22 08:15 | 2016-07-25 14:22 | 35 | 2016-07-22 08:15 | 2016-07-25 14:22 | 1.75d | 3.82d |  |  | Kirvesmies 2; Sadevesikourut; Kalle Kuja [50%] | 11.25h | 363.44 | 363.44 |
| 39 | 1.9.5 | Sähköasennukset |  | 1d | 2016-07-22 08:15 | 2016-07-25 08:15 | 35 | 2016-07-22 08:15 | 2016-07-25 08:15 | 1d | 1.3d | 0d |  | Sähkömies | 7.5h | 650 | 650 |
| 40 | 1.9.6 | Valaisimien asennus |  | 2h | 2016-07-28 08:15 | 2016-07-28 10:15 | 36, 37 | 2016-07-28 08:15 | 2016-07-28 10:15 | 2h | 1.3d |  |  | Sähkömies | 2h | 650 | 650 |
| 41 | 1.9.7 | Maalaustyöt |  | 3d | 2016-07-22 08:15 | 2016-07-29 08:15 | 35 | 2016-07-22 08:15 | 2016-07-29 08:15 | 3d | 0.57d | 0d | start no later than 2016-07-25 07:00 | Maalari | 22.5h | 750 | 750 |
| 42 | 1.10 | VERHOUSTYÖT VALMIIT | milestone | 0d | 2016-07-29 08:15 | 2016-07-29 08:15 | 34FF, 41 | 2016-07-29 08:15 | 2016-07-29 08:15 |  | 0.57d |  |  |  |  |  |  |
| 43 | 2 | PROJEKTI VALMIS | milestone | 2h | 2016-07-29 13:00 | 2016-07-29 15:00 | 1FF, 42 | 2016-07-29 13:00 | 2016-07-29 15:00 | 2h | 0d |  | must finish on 2016-07-29 15:00 | Kari Keinonen | 2h | 90 | 90 |
